# Budowa obiektu mieszkalnego

Schedule from MS Project, 2007-01-01 to 2007-07-31.

## Calendars

- Standardowy: Mon-Fri 09:00-13:00, 14:00-18:00; Sat-Sun off.

## Resources

| Resource |
| --- |
| Wykonawca prac betonowych |
| Wykonawca prac stolarskich |
| Wykonawca ogrodzenia |
| Wykonawca prac murarskich |
| Główny wykonawca |
| Architekt |
| Właściciel |
| Strona udzielająca kredytu hipotecznego |
| Inspektor |
| Firma elektryczna |
| Wykonawca wykopów w miejscu realizacji |
| Wykonawca instalacji elektrycznych |
| Wykonawca instalacji wodociągowych |
| Wykonawca szkieletu konstrukcji |
| Wykonawca pokrycia dachu |
| Wykonawca instalacji grzewczo-wentylacyjnej |
| Wykonawca izolacji |
| Wykonawca ścianek działowych |
| Wykonawca prac malarskich |
| Wykonawca podłóg |
| Wykonawca odpowiedzialny za montaż sprzętu AGD |
| Wykonawca wykończenia terenu |
| Pomoc domowa |

## Schedule

| ID | WBS | Task | Type | Duration | Start | Finish | Predecessors | Total slack | Resources | Work |
| --- | --- | --- | --- | --- | --- | --- | --- | --- | --- | --- |
| 1 | 1 | **Dom jednorodzinny - Projekt architektoniczny (280 metrów kwadratowych z pełnym podpiwniczeniem)** |  | 152d | 2007-01-01 | 2007-07-31 |  | 0d |  | 1584.53h |
| 2 | 1.1 | **Warunki ogólne** |  | 21d | 2007-01-01 | 2007-01-29 |  | 0d |  | 32.53h |
| 3 | 1.1.1 | Sfinalizowanie planów i opracowanie oszacowań z właścicielem, architektem |  | 20d | 2007-01-01 | 2007-01-26 |  | 0d | Główny wykonawca [50%]; Architekt [50%]; Właściciel [12%]; Strona udzielająca kredytu hipotecznego [12%] | 20.53h |
| 4 | 1.1.2 | Podpisanie kontraktu i dokumentu rozpoczęcia budowy |  | 1d | 2007-01-29 | 2007-01-29 | 3 | 0d | Główny wykonawca; Architekt; Właściciel; Strona udzielająca kredytu hipotecznego | 12h |
| 5 | 1.1.3 | **Złożenie podań o zezwolenia** |  | 0d | 2007-01-29 | 2007-01-29 |  | 0d |  |  |
| 6 | 1.1.3.1 | Uzyskanie zezwolenia na fundamenty | milestone | 0d | 2007-01-29 | 2007-01-29 | 4 | 0d | Główny wykonawca |  |
| 7 | 1.1.3.2 | Uzyskanie zezwolenia na szkielet konstrukcji | milestone | 0d | 2007-01-29 | 2007-01-29 | 4 | 0d | Główny wykonawca |  |
| 8 | 1.1.3.3 | Uzyskanie zezwolenia na instalację elektryczną | milestone | 0d | 2007-01-29 | 2007-01-29 | 4 | 0d | Główny wykonawca |  |
| 9 | 1.1.3.4 | Uzyskanie zezwolenia na instalację wodociągową | milestone | 0d | 2007-01-29 | 2007-01-29 | 4 | 0d | Główny wykonawca |  |
| 10 | 1.1.3.5 | Uzyskanie zezwolenia na instalację grzewczo-wentylacyjną | milestone | 0d | 2007-01-29 | 2007-01-29 | 4 | 0d | Główny wykonawca |  |
| 11 | 1.1.3.6 | Uzyskanie pozostałych zezwoleń | milestone | 0d | 2007-01-29 | 2007-01-29 | 4 | 0d | Główny wykonawca |  |
| 12 | 1.2 | **Prace w miejscu realizacji** |  | 3d | 2007-01-30 | 2007-02-01 |  | 0d |  | 32h |
| 13 | 1.2.1 | Oczyszczenie i planowanie miejsca realizacji |  | 1d | 2007-01-30 | 2007-01-30 | 6, 7, 8, 9, 11, 10 | 0d | Wykonawca wykopów w miejscu realizacji | 8h |
| 14 | 1.2.2 | Montaż tymczasowego zasilania |  | 1d | 2007-01-31 | 2007-01-31 | 13 | 0d | Firma elektryczna | 8h |
| 15 | 1.2.3 | Montaż urządzeń podziemnych |  | 1d | 2007-02-01 | 2007-02-01 | 14 | 0d | Wykonawca instalacji elektrycznych; Wykonawca instalacji wodociągowych | 16h |
| 16 | 1.3 | **Fundamenty** |  | 42d | 2007-02-02 | 2007-04-02 |  | 0d |  | 280h |
| 17 | 1.3.1 | Kopanie fundamentów |  | 3d | 2007-02-02 | 2007-02-06 | 15 | 0d | Wykonawca wykopów w miejscu realizacji | 24h |
| 18 | 1.3.2 | Konstruowanie szalunków ścian piwnic |  | 13d | 2007-02-07 | 2007-02-23 | 17 | 0d | Wykonawca prac betonowych | 104h |
| 19 | 1.3.3 | Wylewanie betonowych fundamentów i ścian piwnic |  | 12d | 2007-02-26 | 2007-03-13 | 18 | 0d | Wykonawca prac betonowych | 96h |
| 20 | 1.3.4 | Utrwalanie ścian piwnic przez 7 dni |  | 7d | 2007-03-14 | 2007-03-22 | 19 | 0d |  |  |
| 21 | 1.3.5 | Demontaż szalunków ścian piwnic |  | 2d | 2007-03-23 | 2007-03-26 | 20 | 0d | Wykonawca prac betonowych | 16h |
| 22 | 1.3.6 | Zaimpregnowanie i zaizolowanie ścian piwnic |  | 2d | 2007-03-27 | 2007-03-28 | 21 | 0d | Wykonawca prac betonowych | 16h |
| 23 | 1.3.7 | Przeprowadzenie inspekcji fundamentów |  | 1d | 2007-03-29 | 2007-03-29 | 22, 17 | 0d | Inspektor | 8h |
| 24 | 1.3.8 | Przysypanie fundamentów |  | 2d | 2007-03-30 | 2007-04-02 | 23 | 0d | Wykonawca wykopów w miejscu realizacji | 16h |

| ID | WBS | Task | Duration | Start | Finish | Predecessors | Total slack | Free slack | Resources | Work |
| --- | --- | --- | --- | --- | --- | --- | --- | --- | --- | --- |
| 25 | 1.4 | **Stawianie szkieletu konstrukcji** | 22d | 2007-04-03 | 2007-05-02 |  | 0d |  |  | 176h |
| 26 | 1.4.1 | Montaż legarów podłogowych parteru | 2d | 2007-04-03 | 2007-04-04 | 24 | 0d |  | Wykonawca szkieletu konstrukcji | 16h |
| 27 | 1.4.2 | Kładzenie desek podłogowych parteru | 2d | 2007-04-05 | 2007-04-06 | 26 | 0d |  | Wykonawca szkieletu konstrukcji | 16h |
| 28 | 1.4.3 | Konstruowanie szkieletów ścian parteru | 4d | 2007-04-09 | 2007-04-12 | 27 | 0d |  | Wykonawca szkieletu konstrukcji | 32h |
| 29 | 1.4.4 | Konstruowanie szkieletów narożnych parteru | 1d | 2007-04-13 | 2007-04-13 | 28 | 0d |  | Wykonawca szkieletu konstrukcji | 8h |
| 30 | 1.4.5 | Montaż legarów podłogowych 1 piętra | 2d | 2007-04-16 | 2007-04-17 | 29 | 0d |  | Wykonawca szkieletu konstrukcji | 16h |
| 31 | 1.4.6 | Kładzenie desek podłogowych 1 piętra | 2d | 2007-04-18 | 2007-04-19 | 30 | 0d |  | Wykonawca szkieletu konstrukcji | 16h |
| 32 | 1.4.7 | Konstruowanie szkieletów ścian 1 piętra | 3d | 2007-04-20 | 2007-04-24 | 31 | 0d |  | Wykonawca szkieletu konstrukcji | 24h |
| 33 | 1.4.8 | Konstruowanie szkieletów narożnych 1 piętra | 2d | 2007-04-25 | 2007-04-26 | 32 | 0d |  | Wykonawca szkieletu konstrukcji | 16h |
| 34 | 1.4.9 | Zakończenie konstruowania szkieletu dachu | 3d | 2007-04-27 | 2007-05-01 | 33 | 0d |  | Wykonawca szkieletu konstrukcji | 24h |
| 35 | 1.4.10 | Przeprowadzenie inspekcji szkieletu konstrukcji | 1d | 2007-05-02 | 2007-05-02 | 34 | 0d |  | Inspektor | 8h |
| 36 | 1.5 | **Pokrywanie** | 22d | 2007-05-02 | 2007-05-31 |  | 0d |  |  | 152h |
| 37 | 1.5.1 | Kładzenie poszycia parteru | 3d | 2007-05-03 | 2007-05-07 | 35 | 0d |  | Wykonawca szkieletu konstrukcji | 24h |
| 38 | 1.5.2 | Kładzenie poszycia 1 piętra | 3d | 2007-05-08 | 2007-05-10 | 37 | 0d |  | Wykonawca szkieletu konstrukcji | 24h |
| 39 | 1.5.3 | Kładzenie desek poszycia dachu | 3d | 2007-05-02 | 2007-05-04 | 34 | 4d | 0d | Wykonawca szkieletu konstrukcji | 24h |
| 40 | 1.5.4 | Montaż materiałów ocieplających, obróbek blacharskich i dachówek | 3d | 2007-05-18 | 2007-05-22 | 48 | 0d |  | Wykonawca pokrycia dachu | 24h |
| 41 | 1.5.5 | Zawieszenie drzwi zewnętrznych na parterze | 1d | 2007-05-23 | 2007-05-23 | 40 | 0d |  | Wykonawca szkieletu konstrukcji | 8h |
| 42 | 1.5.6 | Montaż okien na parterze | 3d | 2007-05-24 | 2007-05-28 | 41 | 0d |  | Wykonawca szkieletu konstrukcji | 24h |
| 43 | 1.5.7 | Montaż okien na 1 piętrze | 3d | 2007-05-29 | 2007-05-31 | 42 | 0d |  | Wykonawca szkieletu konstrukcji | 24h |
| 44 | 1.6 | **Wykończenie zewnętrzne** | 19d | 2007-06-01 | 2007-06-27 |  | 5d |  |  | 152h |
| 45 | 1.6.1 | Wykończenie zewnętrznych prac murarskich | 16d | 2007-06-01 | 2007-06-22 | 43 | 5d | 0d | Wykonawca prac murarskich | 128h |
| 46 | 1.6.2 | Wykończenie elewacji zewnętrznej | 3d | 2007-06-25 | 2007-06-27 | 45 | 5d | 0d | Wykonawca szkieletu konstrukcji | 24h |
| 47 | 1.7 | **Założenie urządzeń i zakończenie robót betonowych** | 21d | 2007-05-07 | 2007-06-04 |  | 4d |  |  | 232h |
| 48 | 1.7.1 | Wstępny montaż instalacji wodociągowej | 5d | 2007-05-11 | 2007-05-17 | 39, 38 | 0d |  | Wykonawca instalacji wodociągowych | 40h |
| 49 | 1.7.2 | Przeprowadzenie inspekcji instalacji wodociągowej | 1d | 2007-05-18 | 2007-05-18 | 48 | 20d | 0d | Inspektor | 8h |
| 50 | 1.7.3 | Wylewanie betonowej podłogi piwnicy | 11d | 2007-05-21 | 2007-06-04 | 49 | 33d |  | Wykonawca prac betonowych | 88h |
| 51 | 1.7.4 | Wstępny montaż instalacji elektrycznej | 5d | 2007-05-11 | 2007-05-17 | 39, 38 | 6d | 0d | Wykonawca instalacji elektrycznych | 40h |
| 52 | 1.7.5 | Przeprowadzenie inspekcji instalacji elektrycznej | 1d | 2007-05-18 | 2007-05-18 | 51 | 6d | 0d | Inspektor | 8h |
| 53 | 1.7.6 | Wstępny montaż instalacji grzewczo-wentylacyjnej | 3d | 2007-05-21 | 2007-05-23 | 52 | 6d | 0d | Wykonawca instalacji grzewczo-wentylacyjnej | 24h |
| 54 | 1.7.7 | Przeprowadzenie inspekcji instalacji grzewczo-wentylacyjnej | 1d | 2007-05-24 | 2007-05-24 | 53 | 24d |  | Inspektor | 8h |
| 55 | 1.7.8 | Wstępny montaż urządzeń komunikacyjnych - telefonu, telewizji kablowej, komputera, alarmu | 2d | 2007-05-07 | 2007-05-08 | 39 | 17d |  | Wykonawca instalacji elektrycznych | 16h |

| ID | WBS | Task | Duration | Start | Finish | Predecessors | Total slack | Free slack | Resources | Work |
| --- | --- | --- | --- | --- | --- | --- | --- | --- | --- | --- |
| 56 | 1.8 | **Wykończenie wnętrz** | 30d | 2007-06-01 | 2007-07-12 |  | 0d |  |  | 408h |
| 57 | 1.8.1 | **Izolowanie** | 11d | 2007-06-01 | 2007-06-15 |  | 0d |  |  | 32h |
| 58 | 1.8.1.1 | Izolowanie ścian - parter | 1d | 2007-06-01 | 2007-06-01 | 37, 43, 55, 53, 51, 38 | 0d |  | Wykonawca izolacji | 8h |
| 59 | 1.8.1.2 | Izolowanie ścian - 1 piętro | 1d | 2007-06-04 | 2007-06-04 | 58 | 27d | 3d | Wykonawca izolacji | 8h |
| 60 | 1.8.1.3 | Izolowanie sufitu - 1 piętro | 1d | 2007-06-14 | 2007-06-14 | 66, 59 | 24d | 0d | Wykonawca izolacji | 8h |
| 61 | 1.8.1.4 | Przeprowadzenie inspekcji izolacji | 1d | 2007-06-15 | 2007-06-15 | 60 | 24d |  | Inspektor | 8h |
| 62 | 1.8.2 | **Płyty gipsowe i styropianowe** | 9d | 2007-06-04 | 2007-06-14 |  | 0d |  |  | 80h |
| 63 | 1.8.2.1 | Montaż płyt gipsowych - ściany na parterze | 2d | 2007-06-04 | 2007-06-05 | 58 | 0d |  | Wykonawca ścianek działowych | 16h |
| 64 | 1.8.2.2 | Montaż płyt styropianowych - sufit podwieszany na parterze | 2d | 2007-06-06 | 2007-06-07 | 63 | 0d |  | Wykonawca ścianek działowych | 16h |
| 65 | 1.8.2.3 | Montaż płyt gipsowych - ściany na 1 piętrze | 2d | 2007-06-08 | 2007-06-11 | 64, 59 | 24d | 0d | Wykonawca ścianek działowych | 16h |
| 66 | 1.8.2.4 | Montaż płyt styropianowych - sufit podwieszany na 1 piętrze | 2d | 2007-06-12 | 2007-06-13 | 65 | 24d | 0d | Wykonawca ścianek działowych | 16h |
| 67 | 1.8.2.5 | Uszczelnianie taśmą i szpachlowanie płyt gipsowych na parterze | 1d | 2007-06-08 | 2007-06-08 | 64 | 0d |  | Wykonawca ścianek działowych | 8h |
| 68 | 1.8.2.6 | Uszczelnianie taśmą i szpachlowanie płyt gipsowych na 1 piętrze | 1d | 2007-06-14 | 2007-06-14 | 66, 67 | 33d |  | Wykonawca ścianek działowych | 8h |
| 69 | 1.8.3 | **Malowanie i tapetowanie** | 17d | 2007-06-11 | 2007-07-03 |  | 0d |  |  | 72h |
| 70 | 1.8.3.1 | Nadawanie faktur wszystkim powierzchniom z wyjątkiem wejścia i kuchni - parter | 1d | 2007-06-11 | 2007-06-11 | 67 | 0d |  | Wykonawca prac malarskich | 8h |
| 71 | 1.8.3.2 | Malowanie wszystkich powierzchni z wyjątkiem wejścia i kuchni - parter | 1d | 2007-06-12 | 2007-06-12 | 70 | 0d |  | Wykonawca prac malarskich | 8h |
| 72 | 1.8.3.3 | Tapetowanie wejścia i kuchni - parter | 1d | 2007-06-13 | 2007-06-13 | 71 | 0d |  | Wykonawca prac malarskich | 8h |
| 73 | 1.8.3.4 | Nadawanie faktur wszystkim powierzchniom - 1 piętro | 1d | 2007-06-12 | 2007-06-12 | 70 | 34d | 0d | Wykonawca prac malarskich | 8h |
| 74 | 1.8.3.5 | Malowanie wszystkich powierzchni - 1 piętro | 1d | 2007-06-13 | 2007-06-13 | 73 | 34d |  | Wykonawca prac malarskich | 8h |
| 75 | 1.8.3.6 | Malowanie i dopasowywanie elewacji zewnętrznej | 4d | 2007-06-28 | 2007-07-03 | 46 | 5d | 0d | Wykonawca prac malarskich | 32h |
| 76 | 1.8.4 | **Szafki** | 6d | 2007-06-14 | 2007-06-21 |  | 0d |  |  | 48h |
| 77 | 1.8.4.1 | Prace montażowe na parterze - szafki kuchenne | 2d | 2007-06-14 | 2007-06-15 | 72 | 0d |  | Wykonawca prac stolarskich | 16h |
| 78 | 1.8.4.2 | Prace montażowe na parterze - główna łazienka i szafki dla gości | 1d | 2007-06-18 | 2007-06-18 | 77 | 0d |  | Wykonawca prac stolarskich | 8h |
| 79 | 1.8.4.3 | Prace montażowe na 1 piętrze - łazienka w korytarzu i szafki w łazienkach prywatnych | 1d | 2007-06-19 | 2007-06-19 | 78 | 1d | 0d | Wykonawca prac stolarskich | 8h |
| 80 | 1.8.4.4 | Montaż ramiaków, listew przysufitowych i ościeżnicowych | 2d | 2007-06-20 | 2007-06-21 | 79 | 20d |  | Wykonawca prac stolarskich | 16h |

| ID | WBS | Task | Duration | Start | Finish | Predecessors | Total slack | Free slack | Resources | Work |
| --- | --- | --- | --- | --- | --- | --- | --- | --- | --- | --- |
| 81 | 1.8.5 | **Wykończenie instalacji wodociągowej** | 6d | 2007-06-18 | 2007-06-25 |  | 0d |  |  | 48h |
| 82 | 1.8.5.1 | Wykończenie parteru - instalacja wodociągowa w kuchni | 1d | 2007-06-18 | 2007-06-18 | 77, 49 | 0d |  | Wykonawca instalacji wodociągowych | 8h |
| 83 | 1.8.5.2 | Wykończenie parteru - instalacja wodociągowa w głównej łazience i łazienkach dla gości | 2d | 2007-06-19 | 2007-06-20 | 82, 78 | 0d |  | Wykonawca instalacji wodociągowych | 16h |
| 84 | 1.8.5.3 | Wykończenie 1 piętra - instalacja wodociągowa w łazience na korytarzu i w łazienkach prywatnych | 2d | 2007-06-21 | 2007-06-22 | 83, 79 | 0d |  | Wykonawca instalacji wodociągowych | 16h |
| 85 | 1.8.5.4 | Przeprowadzenie końcowej inspekcji instalacji wodociągowej | 1d | 2007-06-25 | 2007-06-25 | 84 | 0d |  | Inspektor | 8h |
| 86 | 1.8.6 | **Wykończenie instalacji elektrycznej** | 3d | 2007-06-25 | 2007-06-27 |  | 1d |  |  | 40h |
| 87 | 1.8.6.1 | Wyprowadzenie obwodów elektrycznych parteru do panelu sterującego | 1d | 2007-06-25 | 2007-06-25 | 84, 52 | 3d | 0d | Wykonawca instalacji elektrycznych | 8h |
| 88 | 1.8.6.2 | Wyprowadzenie obwodów elektrycznych 1 piętra do panelu sterującego | 1d | 2007-06-26 | 2007-06-26 | 87 | 3d | 0d | Wykonawca instalacji elektrycznych | 8h |
| 89 | 1.8.6.3 | Przeprowadzenie końcowej inspekcji instalacji elektrycznej | 1d | 2007-06-27 | 2007-06-27 | 88 | 3d |  | Inspektor | 8h |
| 90 | 1.8.6.4 | Wykończenie okablowania urządzeń komunikacyjnych - telefonu, telewizji kablowej, komputera, alarmu | 2d | 2007-06-26 | 2007-06-27 | 85 | 0d |  | Wykonawca instalacji elektrycznych | 16h |
| 91 | 1.8.7 | **Wykończenie instalacji grzewczo-wentylacyjnej** | 3d | 2007-06-28 | 2007-07-02 |  | 0d |  |  | 24h |
| 92 | 1.8.7.1 | Wykończenie parteru - strefa 1 instalacji grzewczo-wentylacyjnej | 1d | 2007-06-28 | 2007-06-28 | 90, 54 | 0d |  | Wykonawca instalacji grzewczo-wentylacyjnej | 8h |
| 93 | 1.8.7.2 | Wykończenie 1piętra - strefa 2 instalacji grzewczo-wentylacyjnej | 1d | 2007-06-29 | 2007-06-29 | 92 | 0d |  | Wykonawca instalacji grzewczo-wentylacyjnej | 8h |
| 94 | 1.8.7.3 | Przeprowadzenie inspekcji instalacji grzewczo-wentylacyjnej | 1d | 2007-07-02 | 2007-07-02 | 93 | 0d |  | Inspektor | 8h |
| 95 | 1.8.8 | **Wykładziny dywanowe, glazury i sprzęt AGD** | 8d | 2007-07-03 | 2007-07-12 |  | 0d |  |  | 64h |
| 96 | 1.8.8.1 | Układanie glazury w wejściu, kuchni i łazienkach | 3d | 2007-07-03 | 2007-07-05 | 89, 94 | 0d |  | Wykonawca podłóg | 24h |
| 97 | 1.8.8.2 | Układanie wykładzin dywanowych na parterze | 2d | 2007-07-06 | 2007-07-09 | 96 | 0d |  | Wykonawca podłóg | 16h |
| 98 | 1.8.8.3 | Układanie wykładzin dywanowych na 1 piętrze | 2d | 2007-07-10 | 2007-07-11 | 97 | 0d |  | Wykonawca podłóg | 16h |
| 99 | 1.8.8.4 | Montaż sprzętu AGD | 1d | 2007-07-12 | 2007-07-12 | 98 | 0d |  | Wykonawca odpowiedzialny za montaż sprzętu AGD | 8h |
| 100 | 1.9 | **Kształtowanie terenu i roboty ziemne** | 12d | 2007-07-04 | 2007-07-19 |  | 0d |  |  | 56h |
| 101 | 1.9.1 | Wylewanie betonowego podjazdu i chodników | 2d | 2007-07-04 | 2007-07-05 | 75 | 5d |  | Wykonawca prac betonowych | 16h |
| 102 | 1.9.2 | Montaż ogrodzenia za domem | 2d | 2007-07-13 | 2007-07-16 | 99, 101 | 0d |  | Wykonawca ogrodzenia | 16h |
| 103 | 1.9.3 | Kładzenie darni i sadzenie roślin przed domem | 2d | 2007-07-17 | 2007-07-18 | 102 | 0d |  | Wykonawca wykończenia terenu | 16h |
| 104 | 1.9.4 | Kładzenie darni i sadzenie roślin za domem | 1d | 2007-07-19 | 2007-07-19 | 103 | 0d |  | Wykonawca wykończenia terenu | 8h |

| ID | WBS | Task | Duration | Start | Finish | Predecessors | Total slack | Resources | Work |
| --- | --- | --- | --- | --- | --- | --- | --- | --- | --- |
| 105 | 1.10 | **Akceptacja końcowa** | 8d | 2007-07-20 | 2007-07-31 |  | 0d |  | 64h |
| 106 | 1.10.1 | Zakończenie inspekcji końcowej w celu uzyskania zezwolenia na zasiedlenie | 1d | 2007-07-20 | 2007-07-20 | 104, 94, 89, 85, 61, 80, 50 | 0d | Inspektor | 8h |
| 107 | 1.10.2 | Porządkowanie przed zasiedleniem | 1d | 2007-07-23 | 2007-07-23 | 99, 106 | 0d | Pomoc domowa | 8h |
| 108 | 1.10.3 | Przeprowadzenie obchodu końcowego | 1d | 2007-07-24 | 2007-07-24 | 107 | 0d | Właściciel | 8h |
| 109 | 1.10.4 | Skompletowanie listy usterek | 5d | 2007-07-25 | 2007-07-31 | 108 | 0d | Główny wykonawca | 40h |
