# zadanie inwestycyjne

Schedule from MS Project, 2012-01-02 to 2013-01-07.

## Calendars

- Standardowy: Mon-Fri 07:00-15:00; Sat-Sun off. Exceptions (off unless hours are given): 2011-11-11 to 2015-11-11 (dzien wolny, recurring).

## Schedule

| ID | WBS | Task | Type | Duration | Start | Finish | Predecessors | Total slack | Free slack |
| --- | --- | --- | --- | --- | --- | --- | --- | --- | --- |
| 1 | 1 | **Etap przygotowania programu inwestycji (PI) lub programu organizacyjno – użytkowego (POU)** |  | 111d | 2012-01-02 | 2012-06-04 |  | 0d |  |
| 2 | 1.1 | **Analiza i weryfikacja Minimalnych wojskowych wymagań organizacyjno – użytkowych (MWWOU), w tym:** |  | 8d | 2012-01-02 | 2012-01-11 |  | 0d |  |
| 3 | 1.1.1 | weryfikacja MWWOU pod względem formalnym, |  | 5d | 2012-01-02 | 2012-01-06 |  | 3d |  |
| 4 | 1.1.2 | weryfikacja MWWOU pod względem merytorycznym, |  | 5d | 2012-01-02 | 2012-01-06 |  | 0d |  |
| 5 | 1.1.3 | określenie zakresu rzeczowego planowanego zadania i oszacowanie jego wartości; |  | 3d | 2012-01-09 | 2012-01-11 | 4 | 0d |  |
| 6 | 1.2 | Przygotowanie wniosku w sprawie rozpoczęcia realizacji zadania |  | 4d | 2012-01-12 | 2012-01-17 | 2 | 0d |  |
| 7 | 1.3 | Zatwierdzenie wniosku w sprawie rozpoczęcia realizacji zadania | milestone | 0d | 2012-01-17 | 2012-01-17 | 6 | 0d |  |
| 8 | 1.4 | **Procedura udzielenia zamówienia publicznego dotyczącego opracowania PI lub POU, w tym:** |  | 22d | 2012-01-17 | 2012-02-16 | 7 | 0d |  |
| 9 | 1.4.1 | postępowanie w sprawie udzielenia zamówienia; |  | 30ed | 2012-01-17 | 2012-02-16 |  | 2d | 0d |
| 10 | 1.4.2 | zawarcie umowy na wykonanie PI lub POU. | milestone | 0d | 2012-02-16 | 2012-02-16 | 9 | 0d |  |
| 11 | 1.5 | **Procedura nadzoru na opracowaniem PI lub POU, w tym:** |  | 60d | 2012-02-17 | 2012-05-10 | 8 | 0d |  |
| 12 | 1.5.1 | bieżąca weryfikacja postępów w opracowaniu PI lub POU; |  | 60d | 2012-02-17 | 2012-05-10 |  | 0d |  |
| 13 | 1.5.2 | precyzowanie zakresu rzeczowego do PI. |  | 60d | 2012-02-17 | 2012-05-10 |  | 0d |  |
| 14 | 1.6 | **Procedura odbioru i zatwierdzenia PI lub POU, w tym:** |  | 17d | 2012-05-11 | 2012-06-04 | 11 | 0d |  |
| 15 | 1.6.1 | weryfikacja złożonych opracowań (PI lub POU); |  | 5d | 2012-05-11 | 2012-05-17 |  | 0d |  |
| 16 | 1.6.2 | powołanie Komisji Oceny Projektów Inwestycyjnych i Remontowych (KOPIiR); |  | 1d | 2012-05-18 | 2012-05-18 | 15 | 0d |  |
| 17 | 1.6.3 | sporządzenie protokołu KOPIiR; |  | 1d | 2012-05-21 | 2012-05-21 | 16 | 0d |  |
| 18 | 1.6.4 | zatwierdzenie protokołu KOPIiR | milestone | 0d | 2012-05-21 | 2012-05-21 | 17 | 0d |  |
| 19 | 1.6.5 | zatwierdzenia PI lub POU. |  | 10d | 2012-05-22 | 2012-06-04 | 18 | 0d |  |
| 20 | 2 | **Etap przygotowania dokumentacji projektowo – kosztorysowej (DT)** |  | 155d | 2012-06-04 | 2013-01-07 | 1 | 0d |  |
| 21 | 2.1 | Przygotowanie wniosku w sprawie kontynuacji realizacji zadania w zakresie opracowania DT. |  | 5d | 2012-06-05 | 2012-06-11 |  | 0d |  |
| 22 | 2.2 | Zatwierdzenie wniosku w sprawie kontynuacji realizacji zadania w zakresie opracowania DT. | milestone | 0d | 2012-06-11 | 2012-06-11 | 21 | 0d |  |
| 23 | 2.3 | Procedura udzielenia zamówienia publicznego dotyczącego opracowania DT, |  | 30ed | 2012-06-11 | 2012-07-11 | 22 | 0d |  |
| 24 | 2.4 | Zawarcie umowy na wykonanie DT. | milestone | 0d | 2012-07-11 | 2012-07-11 | 23 | 0d |  |
| 25 | 2.5 | Procedura nadzoru na opracowaniem DT - bieżący nadzór nad opracowaniem DT |  | 180ed | 2012-07-11 | 2013-01-07 | 24 | 0d |  |

Notes:
- 10: data musi byc ustalona w trakcie trwania projektu

| ID | WBS | Task | Type | Duration | Start | Finish | Predecessors | Total slack |
| --- | --- | --- | --- | --- | --- | --- | --- | --- |
| 26 | 2.6 | **Procedura odbioru i zatwierdzenia DT, w tym:** |  | 17d | 2012-06-05 | 2012-06-27 |  | 138d |
| 27 | 2.6.1 | weryfikacja złożonych opracowań (DT); |  | 5d | 2012-06-05 | 2012-06-11 |  | 138d |
| 28 | 2.6.2 | powołanie Komisji Oceny Projektów Inwestycyjnych i Remontowych (KOPIiR); |  | 1d | 2012-06-12 | 2012-06-12 | 27 | 138d |
| 29 | 2.6.3 | sporządzenie protokołu KOPIiR; |  | 1d | 2012-06-13 | 2012-06-13 | 28 | 138d |
| 30 | 2.6.4 | Zatwierdzenie protokołu KOPIiR; | milestone | 0d | 2012-06-13 | 2012-06-13 | 29 | 138d |
| 31 | 2.6.5 | zatwierdzenie Zestawienia Kosztów Zadania (ZKZ). |  | 10d | 2012-06-14 | 2012-06-27 | 30 | 138d |
| 32 | 2.7 | Złożenie wniosku o korektę parametrów planistycznych zadania - korekta właściwych planów rzeczowych. | milestone | 0d | 2012-06-04 | 2012-06-04 |  | 155d |
| 33 | 3 | **Etap realizacji i rozliczenia zadania inwestycyjnego** |  | 1d? | 2012-01-02 | 2012-01-02 |  | 265d |
| 34 | 3.1 | Przygotowanie i zatwierdzenie wniosku w sprawie kontynuacji realizacji zadania w zakresie realizacji robót budowlanych. |  | 1d? | 2012-01-02 | 2012-01-02 |  | 265d |
| 35 | 3.2 | Procedura udzielenia zamówienia publicznego dotyczącego realizacji robót budowlanych - zawarcie umowy na wykonanie robót budowlanych. |  | 1d? | 2012-01-02 | 2012-01-02 |  | 265d |
| 36 | 3.3 | Procedura aktualizacji ZKZ po podpisaniu umowy na realizację robót budowlanych. |  | 1d? | 2012-01-02 | 2012-01-02 |  | 265d |
| 37 | 3.4 | **Procedura przekazania placu budowy, w tym:** |  | 1d? | 2012-01-02 | 2012-01-02 |  | 265d |
| 38 | 3.4.1 | przekazanie kompletnej DT do wykonawcy robót i użytkownika; |  | 1d? | 2012-01-02 | 2012-01-02 |  | 265d |
| 39 | 3.4.2 | przekazanie placu budowy. | milestone | 0d | 2012-01-02 | 2012-01-02 |  | 266d |
| 40 | 3.5 | **Procedura nadzoru inwestorskiego, w tym:** |  | 1d? | 2012-01-02 | 2012-01-02 |  | 265d |
| 41 | 3.5.1 | kontrola jakości wykonywanych robót; |  | 1d? | 2012-01-02 | 2012-01-02 |  | 265d |
| 42 | 3.5.2 | kontrola jakości wbudowywanych materiałów; |  | 1d? | 2012-01-02 | 2012-01-02 |  | 265d |
| 43 | 3.5.3 | odbiory robót zanikających, ulegających zakryciu lub stanowiących zamknięty etap wraz z ich rozliczeniem. |  | 1d? | 2012-01-02 | 2012-01-02 |  | 265d |
| 44 | 3.6 | **Procedura odbioru końcowego i przekazania do eksploatacji, w tym:** |  | 1d? | 2012-01-02 | 2012-01-02 |  | 265d |
| 45 | 3.6.1 | przygotowanie procedury odbioru końcowego; |  | 1d? | 2012-01-02 | 2012-01-02 |  | 265d |
| 46 | 3.6.2 | weryfikacja dokumentacji powykonawczej i pomiarowej; |  | 1d? | 2012-01-02 | 2012-01-02 |  | 265d |
| 47 | 3.6.3 | powołanie komisji odbioru robót; |  | 1d? | 2012-01-02 | 2012-01-02 |  | 265d |
| 48 | 3.6.4 | sporządzenie protokołu z odbioru końcowego i przekazania do eksploatacji efektów rzeczowych zadania. | milestone | 0d | 2012-01-02 | 2012-01-02 |  | 266d |
| 49 | 3.7 | **Procedura przekazania na ewidencję ilościowo – wartościową i rozliczenie zadania.** |  | 1d? | 2012-01-02 | 2012-01-02 |  | 265d |
| 50 | 3.7.1 | sporządzenie protokołów podziału efektów rzeczowych zadania na środki trwałe i środki zwiększające wartość obiektu, |  | 1d? | 2012-01-02 | 2012-01-02 |  | 265d |
| 51 | 3.7.2 | przygotowanie i przesłanie do właściwego oddziału gospodarczego druków PT zgodnie z zapisami protokołu odbioru |  | 1d? | 2012-01-02 | 2012-01-02 |  | 265d |
| 52 | 3.7.3 | przekazanie dokumentacji powykonawczej wraz z dokumentacja budowy do instytucji wskazanych w protokole odbioru |  | 1d? | 2012-01-02 | 2012-01-02 |  | 265d |
| 53 | 3.7.4 | rejestracja potwierdzeń przyjęcia na ewidencję ilościowo – wartościową. | milestone | 0d | 2012-01-02 | 2012-01-02 |  | 266d |
