# Remont sypialni i łazienki

Schedule from MS Project, 2018-06-25 to 2018-10-03, status date 2018-07-02, costs in zł, A marks actual dates.

## Calendars

- Standardowy: Mon-Fri 09:00-13:00, 14:00-18:00; Sat-Sun off.

## Resources

| Resource | Group | Unit | Rate | Notes |
| --- | --- | --- | --- | --- |
| Mama | Rodzina |  | 10 | opis |
| Tata | Rodzina |  | 10 |  |
| Laptop | Sprzęt |  |  |  |
| Ekipa łazienka | Łazienka |  |  |  |
| Ekipa sypialnia | Sypialnia |  |  |  |
| kafelki | Materiały | m2 | 90 |  |
| papier drukarki | Materiały | ryza | 20 |  |
| łóżko | Sypialnia |  |  |  |
| Pomocnik | Pomoc |  | 10 |  |

## Schedule

| ID | WBS | Task | Type | Duration | Start | Finish | Predecessors | Complete | Remaining | Baseline start | Baseline finish | Baseline duration | Baseline 1 start | Baseline 1 finish | Total slack | Resources | Work | Actual work | Cost | Baseline cost | Actual cost |
| --- | --- | --- | --- | --- | --- | --- | --- | --- | --- | --- | --- | --- | --- | --- | --- | --- | --- | --- | --- | --- | --- |
| 1 | 1 | Rozpoczęcie | milestone | 0d | 2018-06-25 A | 2018-06-25 A |  | 100% |  | 2017-12-08 | 2017-12-08 | 0d | 2017-12-11 | 2017-12-11 |  |  |  |  | 2,000 |  | 2,000 |
| 2 | 2 | **Planowanie** |  | 55.56d | 2018-06-25 A | 2018-09-10 A | 1 | 100% |  | 2017-12-08 | 2018-02-23 | 55.56d | 2017-12-11 | 2018-02-26 |  |  | 277.33h | 277.33h | 2,420.22 | 2,880.22 | 2,420.22 |
| 3 | 2.1 | Szukanie inspiracji |  | 6d | 2018-06-25 A | 2018-07-02 A |  | 100% |  | 2017-12-08 | 2017-12-21 | 10d | 2017-12-11 | 2017-12-22 |  | Tata; Mama [50%] | 64h | 64h | 340 | 800 | 340 |
| 4 | 2.2 | Oglądanie |  | 55.56d | 2018-06-25 A | 2018-09-10 A | 1 | 100% |  | 2017-12-08 | 2018-02-23 | 55.56d | 2017-12-11 | 2018-02-26 |  | Mama [30%]; Tata [30%] | 173.33h | 173.33h | 1,733.33 | 1,733.33 | 1,733.33 |
| 5 | 2.3 | Wyszukiwanie |  | 10.24d | 2018-06-25 A | 2018-07-06 A | 1 | 100% |  | 2017-12-08 | 2017-12-21 | 10.24d | 2017-12-11 | 2017-12-22 |  | Tata [20%]; Mama [20%]; Laptop; papier drukarki [2 ryza] | 40h | 40h | 346.89 | 346.89 | 346.89 |
| 6 | 3 | **Poszukiwanie wykonawcy** |  | 5d | 2018-09-10 A | 2018-09-17 | 2 | 63% | 1.88d | 2018-02-23 | 2018-03-02 | 5d | 2018-02-26 | 2018-03-05 | 0d |  | 80h | 50h | 800 | 800 | 500 |
| 7 | 3.1 | Znalezienie środków |  | 5d | 2018-09-10 A | 2018-09-17 A |  | 100% |  | 2018-02-23 | 2018-03-02 | 5d | 2018-02-26 | 2018-03-05 |  | Tata | 40h | 40h | 400 | 400 | 400 |
| 8 | 3.2 | Znalezienie wykonawcy |  | 5d | 2018-09-10 A | 2018-09-17 |  | 25% | 3.75d | 2018-02-23 | 2018-03-02 | 5d | 2018-02-26 | 2018-03-05 | 0d | Tata | 40h | 10h | 400 | 400 | 100 |
| 9 | 4 | **Przygotowanie** |  | 2.5d | 2018-09-17 A | 2018-09-20 | 6 | 50% | 1.25d | 2018-03-02 | 2018-03-07 | 2.5d | 2018-03-05 | 2018-03-08 | 0d |  | 96h | 48h | 960 | 960 | 480 |
| 10 | 4.1 | Pakowanie |  | 1.5d | 2018-09-17 A | 2018-09-19 A |  | 100% |  | 2018-03-02 | 2018-03-06 | 1.5d | 2018-03-05 | 2018-03-07 |  | Pomocnik [200%]; Mama; Tata | 48h | 48h | 480 | 480 | 480 |
| 11 | 4.2 | Wynoszenie |  | 1d | 2018-09-18 | 2018-09-19 | 6FS+1d |  |  | 2018-03-05 | 2018-03-06 | 1d | 2018-03-06 | 2018-03-07 | 0d | Pomocnik [200%]; Mama; Tata | 32h |  | 320 | 320 |  |
| 12 | 4.3 | Przygotowanie |  | 0.5d | 2018-09-19 | 2018-09-20 | 11, 10 |  |  | 2018-03-06 | 2018-03-07 | 0.5d | 2018-03-07 | 2018-03-08 | 0d | Mama; Tata; Pomocnik [200%] | 16h |  | 160 | 160 |  |
| 13 | 5 | **Prace remontowe** |  | 5d | 2018-09-20 | 2018-09-27 | 9 |  |  | 2018-03-07 | 2018-03-14 | 5d | 2018-03-08 | 2018-03-15 | 0d |  |  |  | 40,100 | 40,100 |  |
| 14 | 5.1 | Sypialnia |  | 5d | 2018-09-20 | 2018-09-27 |  |  |  | 2018-03-07 | 2018-03-14 | 5d | 2018-03-08 | 2018-03-15 | 0d | Ekipa sypialnia [0.1%] |  |  | 18,500 | 18,500 |  |
| 15 | 5.2 | Łazienka |  | 5d | 2018-09-20 | 2018-09-27 |  |  |  | 2018-03-07 | 2018-03-14 | 5d | 2018-03-08 | 2018-03-15 | 0d | Ekipa łazienka [0.1%]; kafelki [40 m2] |  |  | 21,600 | 21,600 |  |
| 16 | 6 | Odbiór prac |  | 2h | 2018-09-27 | 2018-09-27 | 13 |  |  | 2018-03-14 | 2018-03-14 | 2h | 2018-03-15 | 2018-03-15 | 0d | Tata; Mama | 4h |  | 40 | 40 |  |
| 17 | 7 | Sprzątanie |  | 2d | 2018-09-27 | 2018-10-01 | 16 |  |  | 2018-03-14 | 2018-03-16 | 2d | 2018-03-15 | 2018-03-19 | 0d | Tata; Mama; Pomocnik [200%] | 48h |  | 480 | 480 |  |
| 18 | 8 | Wnoszenie |  | 2d | 2018-10-01 | 2018-10-03 | 17 |  |  | 2018-03-16 | 2018-03-20 | 2d | 2018-03-19 | 2018-03-21 | 0d | Tata; Mama; Pomocnik [200%] | 48h |  | 480 | 480 |  |
| 19 | 9 | Zakończenie remontu | milestone | 0d | 2018-10-03 | 2018-10-03 | 18 |  |  | 2018-03-20 | 2018-03-20 | 0d | 2018-03-21 | 2018-03-21 | 0d | Tata; Mama |  |  |  |  |  |
