# ECDL Zarządzanie projektami

Schedule from MS Project, 2012-03-02 to 2013-03-22.
Budowa domku jednorodzinnego XY

## Calendars

- Standard: Mon-Fri 08:00-12:00, 13:00-17:00; Sat-Sun off.

## Resources

| Resource | Unit |
| --- | --- |
| Kierownik budowy |  |
| Robotnik ogólnobudowlany |  |
| Spycharka |  |
| Samochód 12t |  |
| Koparka |  |
| Beton | m3 |
| Zaprawa cem-wap | m3 |
| Styropian | m2 |
| Tynkarz |  |
| Rury | mb |

## Schedule

| ID | WBS | Task | Duration | Start | Finish | Predecessors | Total slack | Free slack | Resources | Work |
| --- | --- | --- | --- | --- | --- | --- | --- | --- | --- | --- |
| 1 | BU-D1000001 | **etap I stan zerowy** | 22.5d | 2012-03-02 | 2012-04-03 |  | 0d |  |  | 800h |
| 2 | BU-D1000001-1 | **Zagospodarowanie terenu** | 22d | 2012-03-02 | 2012-04-02 |  | 1.5d |  |  | 536h |
| 3 | BU-D1000001-1.1 | niwelacja terenu | 2d | 2012-03-02 | 2012-03-05 |  | 1.5d | 0d | Kierownik budowy [50%]; Robotnik ogólnobudowlany [200%]; Spycharka | 56h |
| 4 | BU-D1000001-1.2 | zagospodarowanie placu terenu | 20d | 2012-03-06 | 2012-04-02 | 3 | 1.5d |  | Robotnik ogólnobudowlany [200%]; Samochód 12t | 480h |
| 5 | BU-D1000001-2 | **Roboty ziemne** | 3.5d | 2012-03-02 | 2012-03-07 |  | 0d |  |  | 4h |
| 6 | BU-D1000001-2.1 | wytyczenie obiektu | 0.5d | 2012-03-02 | 2012-03-02 |  | 0d |  | Kierownik budowy | 4h |
| 7 | BU-D1000001-2.2 | wykopy | 3d | 2012-03-02 | 2012-03-07 | 6 | 0d |  |  |  |
| 8 | BU-D1000001-3 | **Fundamenty** | 17d | 2012-03-07 | 2012-03-30 |  | 0d |  |  | 260h |
| 9 | BU-D1000001-3.2 | ściany fundamentowe | 5d | 2012-03-19 | 2012-03-26 | 11FS+3d | 0d |  | Robotnik ogólnobudowlany [400%]; Beton [15 m3] | 160h |
| 10 | BU-D1000001-3.3 | instalacje Wod Kan wewnątrz fundamentów | 2d | 2012-03-27 | 2012-03-29 | 9FS+1d | 0d |  |  |  |
| 11 | BU-D1000001-3.5 | ławy fundamentowe | 5d | 2012-03-07 | 2012-03-14 | 7 | 0d |  | Robotnik ogólnobudowlany [200%]; Beton [6 m3]; Kierownik budowy [50%] | 100h |
| 12 | BU-D1000001-3.4 | izolacje termiczne I przeciwwilgociowe fundamentów | 2d | 2012-03-28 | 2012-03-30 | 10SS+1d | 0d |  |  |  |
| 13 | BU-D1000001-4 | odbiór etapu I - stanu zerowego | 1d | 2012-04-02 | 2012-04-03 | 12FS+1d | 0d |  |  |  |
| 14 | BU-D1000002 | **etap II stan surowy otwarty** | 152d | 2012-04-04 | 2012-11-02 | 1 | 0d |  |  | 2324h |
| 15 | BU-D1000002-1 | ściany zewnętrzne | 28d | 2012-04-04 | 2012-05-14 | 13FS+1d | 0d |  | Robotnik ogólnobudowlany [400%]; Kierownik budowy [50%]; Beton [2 m3] | 1008h |
| 16 | BU-D1000002-2 | wieńce | 6d | 2012-05-14 | 2012-05-22 | 15 | 0d |  | Beton [4 m3]; Robotnik ogólnobudowlany [200%] | 96h |
| 17 | BU-D1000002-3 | strop parteru | 11d | 2012-05-25 | 2012-06-11 | 16FS+3d | 0d |  | Robotnik ogólnobudowlany [400%]; Beton [6 m3] | 352h |
| 18 | BU-D1000002-4 | **Posadzki** | 10d | 2012-06-12 | 2012-06-26 |  | 93d |  |  | 248h |
| 19 | BU-D1000002-4.1 | podkłady pod posadzki | 5d | 2012-06-12 | 2012-06-19 | 17FS+1d | 93d | 0d | Beton [4 m3]; Robotnik ogólnobudowlany [200%] | 80h |
| 20 | BU-D1000002-4.2 | podłoża - posadzki | 7d | 2012-06-15 | 2012-06-26 | 19SS+3d | 93d |  | Samochód 12t; Beton [5 m3]; Robotnik ogólnobudowlany [200%] | 168h |
| 21 | BU-D1000002-5 | **Więźba dachowa** | 101d | 2012-06-14 | 2012-11-02 |  | 0d |  |  | 620h |
| 22 | BU-D1000002-5.1 | konstrukcja więźby | 45d | 2012-06-14 | 2012-08-16 | 17FS+3d | 0d |  | Kierownik budowy [50%] | 180h |
| 23 | BU-D1000002-5.2 | pokrycia | 51d | 2012-08-16 | 2012-10-26 | 22 | 0d |  | Robotnik ogólnobudowlany | 408h |
| 24 | BU-D1000002-5.3 | rynny I rury spustowe | 4d | 2012-10-26 | 2012-11-01 | 23 | 0d |  | Robotnik ogólnobudowlany; Rury [100 mb] | 32h |
| 25 | BU-D1000002-5.4 | odbiór etapu II - stanu surowego otwartego | 1d | 2012-11-01 | 2012-11-02 | 24 | 0d |  |  |  |
| 26 | BU-D1000003 | Etap III - stan surowy zamknięty | 2mo | 2012-11-02 | 2012-12-28 | 14 | 0d |  |  |  |
| 27 | BU-D1000004 | Etap IV - stan deweloperski | 3mo | 2012-12-28 | 2013-03-22 | 26 | 0d |  |  |  |
