# ECDL Zarządzanie projektami

Schedule from MS Project, 2012-03-02 to 2013-03-22, status date 2012-05-21, A marks actual dates.
Budowa domku jednorodzinnego XY

## Calendars

- Standard: Mon-Fri 08:00-12:00, 13:00-17:00; Sat-Sun off.

## Resources

| Resource | Unit |
| --- | --- |
| Kierownik budowy |  |
| Robotnik ogólnobudowlany |  |
| Spycharka |  |
| Samochód 12t |  |
| Koparka |  |
| Beton | m3 |
| Zaprawa cem-wap | m3 |
| Styropian | m2 |
| Tynkarz |  |
| Rury | mb |

## Schedule

| ID | WBS | Task | Duration | Start | Finish | Predecessors | Complete | Remaining | Baseline start | Baseline finish | Baseline duration | Total slack | Free slack | Resources | Work | Actual work |
| --- | --- | --- | --- | --- | --- | --- | --- | --- | --- | --- | --- | --- | --- | --- | --- | --- |
| 1 | BU-D1000001 | **etap I stan zerowy** | 22.38d | 2012-03-02 A | 2012-04-03 A |  | 100% |  | 2012-03-02 | 2012-04-03 | 22.5d |  |  |  | 800h | 800h |
| 2 | BU-D1000001-1 | **Zagospodarowanie terenu** | 21.88d | 2012-03-02 A | 2012-04-02 A |  | 100% |  | 2012-03-02 | 2012-04-02 | 22d |  |  |  | 536h | 536h |
| 3 | BU-D1000001-1.1 | niwelacja terenu | 2d | 2012-03-02 A | 2012-03-05 A |  | 100% |  | 2012-03-02 | 2012-03-05 | 2d |  |  | Kierownik budowy [50%]; Robotnik ogólnobudowlany [200%]; Spycharka | 56h | 56h |
| 4 | BU-D1000001-1.2 | zagospodarowanie placu terenu | 20d | 2012-03-06 A | 2012-04-02 A | 3 | 100% |  | 2012-03-06 | 2012-04-02 | 20d |  |  | Robotnik ogólnobudowlany [200%]; Samochód 12t | 480h | 480h |
| 5 | BU-D1000001-2 | **Roboty ziemne** | 3.38d | 2012-03-02 A | 2012-03-07 A |  | 100% |  | 2012-03-02 | 2012-03-07 | 3.5d |  |  |  | 4h | 4h |
| 6 | BU-D1000001-2.1 | wytyczenie obiektu | 0.5d | 2012-03-02 A | 2012-03-02 A |  | 100% |  | 2012-03-02 | 2012-03-02 | 0.5d |  |  | Kierownik budowy | 4h | 4h |
| 7 | BU-D1000001-2.2 | wykopy | 3d | 2012-03-02 A | 2012-03-07 A | 6 | 100% |  | 2012-03-02 | 2012-03-07 | 3d |  |  |  |  |  |
| 8 | BU-D1000001-3 | **Fundamenty** | 16.88d | 2012-03-07 A | 2012-03-30 A |  | 100% |  | 2012-03-07 | 2012-03-30 | 17d |  |  |  | 260h | 260h |
| 9 | BU-D1000001-3.2 | ściany fundamentowe | 5d | 2012-03-19 A | 2012-03-26 A | 11FS+3d | 100% |  | 2012-03-19 | 2012-03-26 | 5d |  |  | Robotnik ogólnobudowlany [400%]; Beton [15 m3] | 160h | 160h |
| 10 | BU-D1000001-3.3 | instalacje Wod Kan wewnątrz fundamentów | 2d | 2012-03-27 A | 2012-03-29 A | 9FS+1d | 100% |  | 2012-03-27 | 2012-03-29 | 2d |  |  |  |  |  |
| 11 | BU-D1000001-3.5 | ławy fundamentowe | 5d | 2012-03-07 A | 2012-03-14 A | 7 | 100% |  | 2012-03-07 | 2012-03-14 | 5d |  |  | Robotnik ogólnobudowlany [200%]; Beton [6 m3]; Kierownik budowy [50%] | 100h | 100h |
| 12 | BU-D1000001-3.4 | izolacje termiczne I przeciwwilgociowe fundamentów | 2d | 2012-03-28 A | 2012-03-30 A | 10SS+1d | 100% |  | 2012-03-28 | 2012-03-30 | 2d |  |  |  |  |  |
| 13 | BU-D1000001-4 | odbiór etapu I - stanu zerowego | 1d | 2012-04-02 A | 2012-04-03 A | 12FS+1d | 100% |  | 2012-04-02 | 2012-04-03 | 1d |  |  |  |  |  |
| 14 | BU-D1000002 | **etap II stan surowy otwarty** | 151.88d | 2012-04-04 A | 2012-11-02 | 1 | 21% | 120.61d | 2012-04-04 | 2012-11-02 | 152d | 0d |  |  | 2324h | 1080h |
| 15 | BU-D1000002-1 | ściany zewnętrzne | 28d | 2012-04-04 A | 2012-05-14 A | 13FS+1d | 100% |  | 2012-04-04 | 2012-05-14 | 28d |  |  | Robotnik ogólnobudowlany [400%]; Kierownik budowy [50%]; Beton [2 m3] | 1008h | 1008h |
| 16 | BU-D1000002-2 | wieńce | 5.88d | 2012-05-14 A | 2012-05-22 | 15 | 77% | 1.38d | 2012-05-14 | 2012-05-22 | 6d | 0d |  | Beton [4 m3]; Robotnik ogólnobudowlany [200%] | 96h | 72h |
| 17 | BU-D1000002-3 | strop parteru | 11d | 2012-05-25 | 2012-06-11 | 16FS+3d |  |  | 2012-05-25 | 2012-06-11 | 11d | 0d |  | Robotnik ogólnobudowlany [400%]; Beton [6 m3] | 352h |  |
| 18 | BU-D1000002-4 | **Posadzki** | 10d | 2012-06-12 | 2012-06-26 |  |  |  | 2012-06-12 | 2012-06-26 | 10d | 93d |  |  | 248h |  |
| 19 | BU-D1000002-4.1 | podkłady pod posadzki | 5d | 2012-06-12 | 2012-06-19 | 17FS+1d |  |  | 2012-06-12 | 2012-06-19 | 5d | 93d | 0d | Beton [4 m3]; Robotnik ogólnobudowlany [200%] | 80h |  |
| 20 | BU-D1000002-4.2 | podłoża - posadzki | 7d | 2012-06-15 | 2012-06-26 | 19SS+3d |  |  | 2012-06-15 | 2012-06-26 | 7d | 93d |  | Samochód 12t; Beton [5 m3]; Robotnik ogólnobudowlany [200%] | 168h |  |
| 21 | BU-D1000002-5 | **Więźba dachowa** | 101d | 2012-06-14 | 2012-11-02 |  |  |  | 2012-06-14 | 2012-11-02 | 101d | 0d |  |  | 620h |  |
| 22 | BU-D1000002-5.1 | konstrukcja więźby | 45d | 2012-06-14 | 2012-08-16 | 17FS+3d |  |  | 2012-06-14 | 2012-08-16 | 45d | 0d |  | Kierownik budowy [50%] | 180h |  |
| 23 | BU-D1000002-5.2 | pokrycia | 51d | 2012-08-16 | 2012-10-26 | 22 |  |  | 2012-08-16 | 2012-10-26 | 51d | 0d |  | Robotnik ogólnobudowlany | 408h |  |
| 24 | BU-D1000002-5.3 | rynny I rury spustowe | 4d | 2012-10-26 | 2012-11-01 | 23 |  |  | 2012-10-26 | 2012-11-01 | 4d | 0d |  | Robotnik ogólnobudowlany; Rury [100 mb] | 32h |  |
| 25 | BU-D1000002-5.4 | odbiór etapu II - stanu surowego otwartego | 1d | 2012-11-01 | 2012-11-02 | 24 |  |  | 2012-11-01 | 2012-11-02 | 1d | 0d |  |  |  |  |
| 26 | BU-D1000003 | Etap III - stan surowy zamknięty | 2mo | 2012-11-02 | 2012-12-28 | 14 |  |  | 2012-11-02 | 2012-12-28 | 2mo | 0d |  |  |  |  |
| 27 | BU-D1000004 | Etap IV - stan deweloperski | 3mo | 2012-12-28 | 2013-03-22 | 26 |  |  | 2012-12-28 | 2013-03-22 | 3mo | 0d |  |  |  |  |
